# 3GPP_Release-2000

Schedule from MS Project, 2000-01-03 to 2006-12-29, A marks actual dates.

## Calendars

- Standard: Mon-Fri 08:00-12:00, 13:00-17:00; Sat-Sun off.

## Resources

| Resource |
| --- |
| NP |
| N1 |
| N2 |
| N3 |
| N4 |
| N5 |
| TP |
| T1 |
| T2 |
| T3 |
| RP |
| R1 |
| R2 |
| R3 |
| R4 |
| SP |
| S1 |
| S2 |
| S3 |
| S4 |
| S5 |
| PCG |
| GP |
| No |
| CN4 |
| ? |
| WG G2 |
| G2 |
| G1 |
| G4 |
| G3 |
| All |
| Generic |
| MLST |
| G5 |
| S3; G2 |
| WG T2 |
| GP;G1 |
| G4;G5 |
| OMA |
| GP-G2 |
| Yes |
| GP; |
| N4; |
| GP; N1 |
| CT5 |
| C5 |
| C1 |
| C4 |
| C3 |
| C6 |

## Schedule

| ID | WBS | Task | Type | Duration | Start | Finish | Complete | Remaining | Baseline start | Baseline finish | Baseline duration | Total slack | Constraint | Resources | Work | Actual work | Text9 | Text6 | Text1 | Text3 | Text4 | Text5 | Text7 | Text8 | Text2 | Text12 |
| --- | --- | --- | --- | --- | --- | --- | --- | --- | --- | --- | --- | --- | --- | --- | --- | --- | --- | --- | --- | --- | --- | --- | --- | --- | --- | --- |
| 1 | 1 | VERSION 2005 June 22nd |  | 1d | 2000-01-03 | 2000-01-03 |  |  | 2000-01-03 | 2000-01-03 | 1d | 1824d |  |  |  |  | 2044 |  |  |  |  |  |  |  |  |  |
| 2 | 2 | "CTRL + a" to display all the 3GPP fields |  | 1d | 2000-01-03 | 2000-01-03 |  |  | 2000-01-03 | 2000-01-03 | 1d | 1824d |  |  |  |  | 1462 |  |  |  |  |  |  |  |  |  |
| 3 | 3 | Content of Release 7, not frozen |  | 1d | 2000-01-03 | 2000-01-03 |  |  | 2000-01-03 | 2000-01-03 | 1d | 1824d |  |  |  |  | 2058 |  |  |  |  |  |  |  |  |  |
| 5 | 4 | Rel-7 Features listed below |  | 1d? | 2000-01-03 | 2000-01-03 |  |  | 2000-01-03 | 2000-01-03 | 1d? | 1824d |  |  |  |  |  | Rel-7 |  |  |  |  |  |  |  |  |
| 6 | 8.5 | **Multiple Input Multiple Output antennas (MIMO)** |  | 719d? | 2003-03-14 A | 2005-12-15 | 12% | 634.49d? | 2003-03-14 | 2005-12-15 | 719d? | 272d |  | R1 | 23544h | 4190.4h | 2468 | Rel-7 | MIMO | TR25.876,TR25.996 | Howard Huang, Lucent | hchuang@lucent.com | TSG | Cesar |  |  |
| 7 | 5.1 | MIMO - Physical layer |  | 392d? | 2003-09-12 A | 2005-03-15 | 60% | 156.8d? | 2003-09-12 | 2005-03-15 | 392d? | 469d | finish no earlier than 2005-03-15 | R1 | 3136h | 1881.6h |  | Rel-7 | MIMO-Phys | 25.211, 25.212, 25.213, 25.214, 25.215, 25.221, 25 | Howard Huang, Lucent | hchuang@lucent.com | TSG | Cesar |  |  |
| 8 | 5.2 | MIMO - Layer 2,3 aspects |  | 589d? | 2003-09-12 | 2005-12-15 |  |  | 2003-09-12 | 2005-12-15 | 589d? | 272d | finish no earlier than 2005-12-15 | R2 | 4712h |  |  | Rel-7 | MIMO-L23 | TR 25.876 | Howard Huang, Lucent | hchuang@lucent.com | TSG | Cesar |  |  |
| 9 | 5.3 | MIMO - Iub/Iur Protocol Aspects |  | 719d? | 2003-03-14 | 2005-12-15 |  |  | 2003-03-14 | 2005-12-15 | 719d? | 272d | finish no earlier than 2005-12-15 | R3 | 5752h |  |  | Rel-7 | MIMO-IurIub |  | Howard Huang, Lucent | hchuang@lucent.com | TSG | Cesar |  |  |
| 10 | 5.4 | MIMO - RF Radio Transmission/Reception, System Performance Requirements and Conformance Testing |  | 524d? | 2003-12-12 A | 2005-12-15 | 5% | 497.8d? | 2003-12-12 | 2005-12-15 | 524d? | 272d | finish no earlier than 2005-12-15 | R4 | 4192h | 209.6h |  | Rel-7 | MIMO-RF |  | Man Hung Ng, Lucent | ngm@lucent.com | TSG | Cesar |  |  |
| 11 | 6 | **PS domain and IMS impacts for supporting IMS Emergency calls** |  | 1389d? | 2000-08-14 A | 2005-12-08 | 39% | 853.49d? | 2000-08-14 | 2005-12-08 | 1389d? | 276d |  | S2 | 56296h | 17833.4h |  | Rel-7 | EMC1 |  | Rainer Liebhart |  | TSG | Maurice |  |  |
| 12 | 10.1.1 | Service Requirements for IP-based emergency calls |  | 985d | 2000-09-18 A | 2004-06-25 A | 100% |  | 2000-09-18 | 2004-06-25 | 985d |  | finish no earlier than 2004-06-25 | S1 | 7880h | 7880h | 1314 | Rel-7 | EMC1 | 22.976 |  |  |  |  | CCaR |  |
| 13 | 6.2 | Stage 2 for IMS-level solution |  | 668d? | 2003-02-26 A | 2005-09-16 | 85% | 100.2d? | 2003-02-26 | 2005-09-16 | 668d? | 335d | finish no earlier than 2005-09-16 | S2 | 5344h | 4542.4h |  | Rel-7 | EMC1 | 23.228, 23.060, 23.002 | Rainer Liebhart, Siemenws |  | TSG |  |  |  |
| 14 | 6.3 | Stage 2 for GPRS-level solution |  | 301d? | 2004-10-14 A | 2005-12-08 | 50% | 150.5d? | 2004-10-14 | 2005-12-08 | 301d? | 276d | finish no earlier than 2005-12-08 | S2 | 2408h | 1204h |  | Rel-7 | EMC1 |  |  |  |  |  |  |  |
| 15 | 10.1 | **Emergency Call Enhancements for IP& PS Based Calls – stage 3** |  | 1280.1d | 2000-08-14 A | 2005-07-11 |  | 1280.1d | 2000-08-14 | 2005-07-11 | 1280.1d | 384.9d |  | C1 | 29752h |  | 1653 | Rel-7 | EMC1 |  | Mr Atle Monrad, Ericsson | Atle.Monrad@eto.ericsson.se |  |  | CCaR |  |
| 16 | 10.1.2 | IMS aspects to support IMS Emergency sessions |  | 1209d | 2000-10-17 A | 2005-07-08 |  | 1209d | 2000-10-17 | 2005-07-08 | 1209d | 385.82d | finish no earlier than 2005-06-03 | C1 | 9672h |  | 1315 | Rel-7 | EMC1 | 24.229 | Mr Atle Monrad, Ericsson | Atle.Monrad@eto.ericsson.se |  |  | CCaR |  |
| 17 | 10.1.5 | PS domain aspects to support IMS Emergency sessions |  | 1255d | 2000-08-14 A | 2005-07-11 |  | 1255d | 2000-08-14 | 2005-07-11 | 1255d | 384.9d | finish no earlier than 2005-06-03 | C1 | 10040h |  | 1646 | Rel-7 | EMC1 | 24.008 | Mr Atle Monrad, Ericsson | Atle.Monrad@eto.ericsson.se |  |  | CCaR |  |
| 18 | 7 | **Access Class Barring and Overload Protection** |  | 274d? | 2004-03-15 A | 2005-03-31 | 80% | 53.68d? | 2004-03-15 | 2005-03-31 | 274d? | 456d |  | S2 | 4928h | 3962.57h |  | Rel-7 | ACBOP | 23.898 | Chris Pudney, Vodafone |  | TSG | Maurice |  |  |
| 19 | 7.1 | TR on Stage 2 |  | 274d? | 2004-03-15 A | 2005-03-31 A | 100% |  | 2004-03-15 | 2005-03-31 | 274d? |  | finish no earlier than 2005-03-31 | S2 | 2192h | 2192h |  | Rel-7 | ACBOP |  |  |  | TSG |  |  |  |
| 20 | 7.2 | Extra ACBOP information in GERAN |  | 67d? | 2004-03-15 | 2004-06-15 |  |  | 2004-03-15 | 2004-06-15 | 67d? | 663d | start no earlier than 2004-03-15 | GP | 536h |  |  | Rel-7 | ACBOP | 44.018 |  |  | TSG |  |  |  |
| 21 | 7.3 | Stage 3 CN aspects of ACBOP |  | 1d? | 2004-12-08 A | 2004-12-08 A | 100% |  | 2004-12-08 | 2004-12-08 | 1d? |  | finish no earlier than 2004-12-08 | C1 | 8h | 8h |  | Rel-7 | ACBOP |  |  |  |  |  |  |  |
| 22 | 7.4 | Deleted - Potential impact on Iu interface Overload functionality | milestone | 0d? | 2004-03-15 A | 2004-03-15 A | 100% |  | 2004-03-15 | 2004-03-15 | 0d? |  | finish no earlier than 2004-03-15 | RP |  |  |  | Rel-7 | ACBOP | 25.413 |  |  |  |  |  | RP-25 |
| 23 | 7.5 | Deleted - Extra ACBOP information in RAN | milestone | 0d? | 2004-03-15 A | 2004-03-15 A | 100% |  | 2004-03-15 | 2004-03-15 | 0d? |  | finish no earlier than 2004-03-15 | RP |  |  |  | Rel-7 | ACBOP | 25.331 |  |  |  |  |  | RP-25 |
| 24 | 8 | **USSD message delivery and transfer to USIM** |  | 443.7d? | 2004-03-05 A | 2005-11-16 | 29% | 313.06d? | 2004-03-05 | 2005-11-16 | 443.7d? | 292.3d |  | S1 | 6781.6h | 1996.71h |  | Rel-7 | USSD-USIM | 22.090 |  |  | TSG | Michael |  |  |
| 25 | 8.1 | Stage 1 |  | 152d? | 2004-03-18 A | 2004-10-15 | 80% | 30.4d? | 2004-03-18 | 2004-10-15 | 152d? | 575d | start no earlier than 2004-03-18 | S1 | 1216h | 972.8h |  | Rel-7 | USSD-USIM | 22.090 |  |  | TSG | Michael |  |  |
| 26 | 8.2 | Alignment with requirements regarding USSD usage |  | 261d? | 2004-03-05 A | 2005-11-16 |  | 261d? | 2004-03-05 | 2005-11-16 | 261d? | 292.3d | finish no earlier than 2005-03-04 | C6 | 2088h |  |  | Rel-7 | USSD-USIM |  | Christophe Dubois (Axalto) | cdubois@axalto.com | TSG |  |  |  |

Notes:
- 21: NEW - inserted on 2/9/2004

| ID | WBS | Task | Type | Duration | Start | Finish | Complete | Remaining | Baseline start | Baseline finish | Baseline duration | Total slack | Constraint | Resources | Work | Actual work | Text1 | Text3 | Text6 | Text8 | Text4 | Text5 | Text7 |
| --- | --- | --- | --- | --- | --- | --- | --- | --- | --- | --- | --- | --- | --- | --- | --- | --- | --- | --- | --- | --- | --- | --- | --- |
| 27 | 9 | **Location Services enhancements Rel-7** |  | 513d? | 2004-06-28 A | 2006-06-15 | 35% | 331.06d? | 2004-06-28 | 2006-06-15 | 513d? | 142d |  | S2 | 22357.6h | 7074.27h | LCS3 | 23.271 | Rel-7 | Maurice |  |  |  |
| 28 | 9.1 | Global Stage 2 for LCS3 |  | 321d? | 2004-12-31 A | 2006-03-24 | 27% | 234.33d? | 2004-12-31 | 2006-03-24 | 321d? | 200d | finish no earlier than 2006-03-24 | S2 | 2568h | 693.36h | LCS3 | 23.271 | Rel-7 | Maurice | Ben Rodilitz, SiRF | brodilitz@sirf.com | TSG |
| 29 | 9.2 | **LCS for 3GPP Interworking WLAN** |  | 329d? | 2004-06-28 A | 2005-09-29 | 65% | 115.15d? | 2004-06-28 | 2005-09-29 | 329d? | 326d |  | S1 | 5165.6h | 1745.24h | LCS3-IWLAN | 22.935 | Rel-7 | Michael | Mike Loushine, (Telcordia) |  | TSG |
| 30 | 9.2.1 | FS on 3GPP system to WLAN Interworking with LCS |  | 316.7d? | 2004-06-28 A | 2005-09-29 | 65% | 110.84d? | 2004-06-28 | 2005-09-29 | 316.7d? | 326d | finish no earlier than 2005-09-29 | S1 | 2533.6h | 1646.84h | LCS3-IWLAN | 22.935 | Rel-7 |  |  |  |  |
| 31 | 9.3 | **UE positioning Rel-7** |  | 456d? | 2004-09-15 A | 2006-06-15 | 35% | 296.78d? | 2004-09-15 | 2006-06-15 | 456d? | 142d |  | RP | 8872h | 3097.73h | LCS3-UEpos |  | Rel-7 | Cesar |  |  | TSG |
| 32 | 9.3.1 | Inclusion of Uplink TDOA UE positioning method in the UTRAN specifications |  | 456d? | 2004-09-15 A | 2006-06-15 | 50% | 228d? | 2004-09-15 | 2006-06-15 | 456d? | 142d | finish no earlier than 2006-06-15 | R2 | 3648h | 1824h | LCS3-UEPos-UTDOA | TS25.305, TS25.453 | Rel-7 | Cesar | Robert Gross, TruePosition | rlgross@trueposition.com | TSG |
| 33 | 9.3.2 | NEW!! LCS Enhancements Related to Location-Based Services |  | 197d? | 2005-03-15 | 2005-12-15 |  |  | 2005-03-15 | 2005-12-15 | 197d? | 272d | finish no earlier than 2005-12-15 | R2 | 1576h |  | LCS3-UEPos-Velocity | 25.305, 25.331, 25.410, 25.413, 25.453 | Rel-7 | Cesar | Ben Rodilitz | BRodilitz@SiRF.com | TSG |
| 34 | 9.4 | LCS Enhancements Related to Location-Based Services |  | 206d? | 2005-01-28 A | 2005-11-11 | 5% | 195.7d? | 2005-01-28 | 2005-11-11 | 206d? | 295d | finish no earlier than 2005-11-11 | GP | 1648h | 82.4h | LCS3-LBS | 43.059, 44.031, 48.008, 49.031 | Rel-7 | Paolo | Kevin Judge, SiRF Technologies | kjudge@sirf.com | TSG |
| 35 | 10 | **Deleted: FS on applicability of GALILEO for LCS** |  | 484d? | 2003-08-25 A | 2005-06-30 |  | 484d? | 2003-08-25 | 2005-06-30 | 484d? | 391d |  | S2 | 3872h | 1000h | Galileo |  | Rel-7 |  |  |  |  |
| 36 | 10.1 | Deleted - TR on Stage 2 | milestone | 0d? | 2005-06-30 A | 2005-06-30 A | 100% |  | 2005-06-30 | 2005-06-30 | 0d? |  | finish no earlier than 2005-06-30 | S2 |  |  | Galileo |  | Rel-7 |  |  |  |  |
| 37 | 10.2 | deleted - GERAN review of the TR | milestone | 0d? | 2003-08-25 | 2003-08-25 |  |  | 2003-08-25 | 2003-08-25 | 0d? | 875d | finish no earlier than 2003-08-25 | GP |  |  | Galileo |  | Rel-7 |  |  |  |  |
| 38 | 11 | **Selective Disabling of UE Capabilities** |  | 489.36d? | 2005-01-24 A | 2006-12-08 | 24% | 373.3d? | 2005-01-24 | 2006-12-08 | 489.36d? | 15d |  | S1 | 8308.8h | 1970.51h | SDoUE | 22.xxx | Rel-7 | Michael | Nigel Barnes (Motorola Ltd) | Nigel.Barnes@motorola.com | TSG |
| 39 | 11.1 | Stage 1 |  | 393.6d? | 2005-01-24 A | 2006-12-08 | 22% | 307.01d? | 2005-01-24 | 2006-12-08 | 393.6d? | 15d | finish no earlier than 2006-12-08 | S1 | 3148.8h | 692.74h | SDoUE-CRs | 22.101 | Rel-7 | Michael | Nigel Barnes (Motorola Ltd) | Nigel.Barnes@motorola.com | TSG |
| 40 | 11.2 | TR on different possible architectures |  | 195d? | 2005-03-21 A | 2005-12-16 | 27% | 142d? | 2005-03-21 | 2005-12-16 | 195d? | 270d | finish no earlier than 2005-12-16 | S2 | 1560h | 424h | SDoUE | 22.805 | Rel-7 | Maurice |  |  |  |
| 41 | 12 | **FS on IMS with real time services deployment** |  | 384d? | 2004-06-28 A | 2005-12-15 | 75% | 95.33d? | 2004-06-28 | 2005-12-15 | 384d? | 271d |  | S1 | 10680h | 6423.44h | IRTSD |  | Rel-7 | Maurice |  |  | TSG |
| 42 | 12.1 | Feasibility Study on Combining CS calls and IMS sessions |  | 384d? | 2004-06-28 A | 2005-12-15 A | 100% |  | 2004-06-28 | 2005-12-15 | 384d? |  | start no earlier than 2004-06-28 | S1 | 3072h | 3072h | IRTSD-CS_IMS | 22.979, 23.899 | Rel-7 | Michael |  |  | TSG |
| 43 | 12.2 | TR on Stage 2 (IMS services using CS bearers) |  | 316d? | 2004-06-28 A | 2005-09-12 | 65% | 110.6d? | 2004-06-28 | 2005-09-12 | 316d? | 339d | finish no earlier than 2005-09-12 | S2 | 2528h | 1643.2h | IRTSD-IMSCS | 23.899 | Rel-7 | Maurice | Mark Watson (Nortel Networks) |  | TSG |
| 44 | 12.3 | Deleted - TS on Stage 2 (IMS services using CS bearers) |  | 251d? | 2004-06-28 A | 2005-06-13 | 50% | 125.5d? | 2004-06-28 | 2005-06-13 | 251d? | 404d | finish no earlier than 2005-06-13 | S2 | 2008h | 1004h | IRTSD-IMSCS |  | Rel-7 | Maurice | Mark Watson (Nortel Networks) |  | TSG |
| 45 | 13 | **Combinational Services** |  | 205d? | 2005-01-17 A | 2005-10-28 | 39% | 125.69d? | 2005-01-17 | 2005-10-28 | 205d? | 305d |  | S1 | 5696h | 2203.69h | CSICS |  | Rel-7 | Michael | Robert Frank, TeliaSonera | Robert.Frank@teliasonera.com | TSG |
| 46 | 13.1 | Stage 1 for CSICS |  | 104d? | 2005-01-17 A | 2005-06-09 | 85% | 15.6d? | 2005-01-17 | 2005-06-09 | 104d? | 406d | start no earlier than 2005-01-17 | S1 | 832h | 707.2h | CSICS | 22.279 | Rel-7 |  |  |  | TSG |
| 47 | 13.2 | Stage 2 for CSICS |  | 130d? | 2005-01-17 A | 2005-07-15 | 75% | 32d? | 2005-01-17 | 2005-07-15 | 130d? | 380d | start no earlier than 2005-01-17 | S2 | 1040h | 784h | CSICS | 23.379 | Rel-7 |  |  |  |  |
| 48 | 13.3 | Stage 3 for CSICS CN aspects |  | 130d? | 2005-05-02 A | 2005-10-28 | 2% | 127.4d? | 2005-05-02 | 2005-10-28 | 130d? | 305d | start no earlier than 2005-05-01 | C1 | 1040h | 20.8h | CSICS | 24.229, 24.008 | Rel-7 | Andrijana | Peter Dawes (Vodafone) |  | TSG |
| 49 | 13.4 | Stage 3 for codec aspects |  | 143d? | 2005-03-15 A | 2005-09-29 | 5% | 135.85d? | 2005-03-15 | 2005-09-29 | 143d? | 326d | finish no earlier than 2005-09-29 | S4 | 1144h | 57.2h | CSICS-Codec | TS 26.141, 26.235, 26.236 | Rel-7 | Paolo | Per Fröjdh, Ericsson | Per.Frojdh@ericsson.com | TSG |
| 50 | 14 | **All-IP Network (AIPN)** |  | 448d? | 2004-06-28 A | 2006-03-15 | 47% | 236.68d? | 2004-06-28 | 2006-03-15 | 448d? | 207d |  | S1 | 8672h | 4090.57h | AIPN | 22.978 | Rel-7 | Michael | Chris Sachno (NTT DoCoMo) | c.masyu@nttdocomo.co.jp | TSG |
| 51 | 14.1 | All-IP Network Feasibility Study |  | 188d? | 2004-06-28 A | 2005-03-16 A | 100% |  | 2004-06-28 | 2005-03-16 | 188d? |  | start no earlier than 2004-06-28 | S1 | 1504h | 1504h | AIPFS | 22.978 | Rel-7 | Michael | Chris Sachno (NTT DoCoMo) | c.masyu@nttdocomo.co.jp | TSG |
| 52 | 14.2 | Stage1 |  | 448d? | 2004-06-28 A | 2006-03-15 | 25% | 336d? | 2004-06-28 | 2006-03-15 | 448d? | 207d | finish no earlier than 2006-03-15 | S1 | 3584h | 896h | AIPN | 22.258 | Rel-7 | Michael | Chris Sachno (NTT DoCoMo) | c.masyu@nttdocomo.co.jp | TSG |
| 53 | 15 | Enhancement of E2E QoS |  | 336.4d? | 2004-06-28 A | 2005-12-01 | 60% | 134.56d? | 2004-06-28 | 2005-12-01 | 336.4d? | 281d | finish no earlier than 2005-12-01 | S2 | 2691.2h | 1614.72h | QoS7 | 23.802 | Rel-7 | Maurice |  |  | TSG |

Notes:
- 28: Approved SA#27. Appropriate place forEmergency work to be found
- 30: DAB - Should be SA1
- 32: Approved at RP#25 as RP-040387
- 34: Linked SP-040682
- 44: covered by 32084
- 49: Started
- 53: DAB - pushed back to June

| ID | WBS | Task | Type | Duration | Start | Finish | Complete | Remaining | Baseline start | Baseline finish | Baseline duration | Total slack | Constraint | Resources | Work | Actual work | Text1 | Text6 | Text7 | Text8 | Text4 | Text5 |
| --- | --- | --- | --- | --- | --- | --- | --- | --- | --- | --- | --- | --- | --- | --- | --- | --- | --- | --- | --- | --- | --- | --- |
| 54 | 16 | **System enhancements for fixed broadband access to IMS** |  | 353d? | 2004-08-03 A | 2005-12-08 | 44% | 196.17d? | 2004-08-03 | 2005-12-08 | 353d? | 276d |  | S2 | 6873.6h | 3053.84h | FBI | Rel-7 | TSG | Maurice |  |  |
| 55 | 16.1 | Stage 2 |  | 235d? | 2004-10-14 A | 2005-09-07 | 40% | 141d? | 2004-10-14 | 2005-09-07 | 235d? | 342d | finish no earlier than 2005-09-07 | S2 | 1880h | 752h | FBI | Rel-7 | TSG | Maurice |  |  |
| 56 | 16.2 | Protocol impact from providing IMS services via fixed broadband |  | 347d? | 2004-08-03 A | 2005-11-30 | 63% | 130d? | 2004-08-03 | 2005-11-30 | 347d? | 282d | finish no earlier than 2005-03-03 | C1 | 2776h | 1736h | FBI | Rel-7 | TSG | Andrijana | Siemens |  |
| 57 | 16.3 | IMS security extensions for Fixed Broadband Access to IMS |  | 118d? | 2005-06-28 | 2005-12-08 |  |  | 2005-06-28 | 2005-12-08 | 118d? | 276d | start no earlier than 2005-06-28 | S3 | 944h |  | ISE | Rel-7 |  | Mike | Bengt Sahlin, Ericsson | Bengt.Sahlin@ericsson.com |
| 58 | 16.7 | **Deleted - IMS Local services** |  | 1158d? | 2001-01-01 A | 2005-06-08 | 68% | 367.35d? | 2001-01-01 | 2005-06-08 | 1158d? | 407d |  | S2 | 13072h | 5192.02h | IMSLocal | Rel-7 |  |  |  |  |
| 59 | 16.7.1 | Deleted - Stage 2 |  | 325d | 2001-01-01 A | 2002-03-29 A | 100% |  | 2001-01-01 | 2002-03-29 | 325d |  | start no earlier than 2001-01-01 | S2 | 2600h | 2600h | IMSLocal | Rel-7 |  |  |  |  |
| 60 | 17.2 | Delete - Stage 3 for IMS Local services |  | 151d? | 2004-11-10 | 2005-06-08 |  |  | 2004-11-10 | 2005-06-08 | 151d? | 407d | finish no earlier than 2005-06-08 | C1 | 1208h |  | IMSLocal | Rel-7 |  |  | Keith Drage, Lucent | drage@lucent.com |
| 61 | 18 | Mp (MRFC - MRFP) interface |  | 644d | 2002-12-13 | 2005-06-01 |  |  | 2002-12-13 | 2005-06-01 | 644d | 412d | finish no earlier than 2005-06-01 | C4 | 5152h |  | IMSLocal | Rel-7 |  |  |  |  |
| 62 | 19 | IMS Stage 3 IETF Protocol alignment |  | 261d? | 2004-12-10 A | 2005-12-09 | 10% | 234.9d? | 2004-12-10 | 2005-12-09 | 261d? | 275d | finish no earlier than 2005-12-09 | C1 | 2088h | 208.8h | IMSProtoc | Rel-7 |  |  |  |  |
| 63 | 20 | **Rel-7 Improvements of the Radio Interface** |  | 390d? | 2004-09-15 A | 2006-03-15 | 39% | 239.41d? | 2004-09-15 | 2006-03-15 | 390d? | 208d |  | RP | 13032h | 5031.89h | RInImp | Rel-7 |  | Cesar |  |  |
| 64 | 20.1 | UMTS 2.6 GHz |  | 195d? | 2004-09-15 A | 2005-06-14 A | 100% |  | 2004-09-15 | 2005-06-14 | 195d? |  | finish no earlier than 2005-06-14 | R4 | 1560h | 1560h | RInImp-UMTS2600 | Rel-7 | TSG | Cesar | Jussi Numminen, Nokia | jussi.numminen@nokia.com |
| 65 | 20.2 | UMTS 2.6 GHz TDD |  | 261d? | 2004-12-15 A | 2005-12-15 | 35% | 169.65d? | 2004-12-15 | 2005-12-15 | 261d? | 272d | finish no earlier than 2005-12-15 | R4 | 2088h | 730.8h | RInImp-UMTS2600TDD | Rel-7 | TSG | Cesar | Shin Horng Wong (IPWireless) | shwong@IPWIRELESS.COM |
| 66 | 20.3 | UMTS 900 MHz |  | 261d? | 2004-12-15 A | 2005-12-15 | 30% | 182.7d? | 2004-12-15 | 2005-12-15 | 261d? | 272d | finish no earlier than 2005-12-15 | R4 | 2088h | 626.4h | RInImp-UMTS900 | Rel-7 | TSG | Cesar | Yannick Li (Nortel) | yli@nortelnetworks.com |
| 67 | 20.4 | NEW!! UMTS 1700 MHz |  | 197d? | 2005-03-15 | 2005-12-15 |  |  | 2005-03-15 | 2005-12-15 | 197d? | 272d | finish no earlier than 2005-12-15 | R4 | 1576h |  | RInImp-UMTS1700 | Rel-7 | TSG | Cesar | Takehiro Nakamura | NTT DoCoMo |
| 68 | 20.5 | UE Antenna Performance Evaluation Method and Requirements |  | 325d? | 2004-12-15 A | 2006-03-15 | 35% | 211.25d? | 2004-12-15 | 2006-03-15 | 325d? | 208d | finish no earlier than 2006-03-15 | R4 | 2600h | 910h | RInImp-UEAnt | Rel-7 | TSG | Cesar | Christian Bergljung (TeliaSonera) | Christian.Bergljung@TeliaSonera.com |
| 69 | 20.6 | NEW!! Improved Performance Requirements for HSDPA UE based on Rx Diversity (type 1) & LMMSE equalizer (type 2) | milestone | 0d? | 2005-03-15 | 2005-03-15 |  |  | 2005-03-15 | 2005-03-15 | 0d? | 469d | finish no earlier than 2005-03-15 | R4 |  |  | RInImp-HSPerf-Type3 | Rel-7 | TSG | Cesar | Marc Grant | marc.grant@cingular.com |
| 70 | 21 | **7.68Mcps TDD option** |  | 456d? | 2004-09-15 A | 2006-06-15 | 20% | 363.97d? | 2004-09-15 | 2006-06-15 | 456d? | 142d |  | RP | 17728h | 3577.83h | VHCRTDD | Rel-7 | TSG | Cesar | Martin Beale, IPWireless | mbeale@ipwireless.com |
| 71 | 21.1 | VHCRTDD: Stage 2 |  | 326d? | 2004-09-15 A | 2005-12-15 | 15% | 277.1d? | 2004-09-15 | 2005-12-15 | 326d? | 272d | finish no earlier than 2005-12-15 | R1 | 2608h | 391.2h | VHCRTDD-Stage2 | Rel-7 | TSG | Cesar | Martin Beale, IPWireless | mbeale@ipwireless.com |
| 72 | 21.2 | VHCRTDD: Physical Layer |  | 326d? | 2004-09-15 A | 2005-12-15 | 15% | 277.1d? | 2004-09-15 | 2005-12-15 | 326d? | 272d | finish no earlier than 2005-12-15 | R1 | 2608h | 391.2h | VHCRTDD-Phys | Rel-7 | TSG | Cesar | Martin Beale, IPWireless | mbeale@ipwireless.com |
| 73 | 21.3 | VHCRTDD: Layer 2 and layer 3 protocol aspects |  | 326d? | 2004-09-15 A | 2005-12-15 | 15% | 277.1d? | 2004-09-15 | 2005-12-15 | 326d? | 272d | finish no earlier than 2005-12-15 | R2 | 2608h | 391.2h | VHCRTDD-L23 | Rel-7 | TSG | Cesar | Derek Richards, IPWireless | drichards@ipwireless.com |
| 74 | 21.4 | VHCRTDD: UTRAN Iub/Iur Protocol Aspects |  | 326d? | 2004-09-15 A | 2005-12-15 | 15% | 277.1d? | 2004-09-15 | 2005-12-15 | 326d? | 272d | finish no earlier than 2005-12-15 | R3 | 2608h | 391.2h | VHCRTDD-IurIub | Rel-7 | TSG | Cesar | Peter Legg, IPWireless | plegg@ipwireless.com |
| 75 | 21.5 | VHCRTDD: RF Radio Transmission/ Reception, System Performance Requirements and Conformance Testing |  | 456d? | 2004-09-15 A | 2006-06-15 | 35% | 296.4d? | 2004-09-15 | 2006-06-15 | 456d? | 142d | finish no earlier than 2006-06-15 | R4 | 3648h | 1276.8h | VHCRTDD-RF | Rel-7 | TSG | Cesar | Shin Horng Wong | shwong@ipwireless.com |
| 76 | 22 | **Rel-7 RAN improvements** |  | 325d? | 2004-12-15 A | 2006-03-15 | 15% | 275.3d? | 2004-12-15 | 2006-03-15 | 325d? | 208d |  | RP | 10424h | 1593.98h | RANimp | Rel-7 | TSG | Cesar |  |  |
| 77 | 22.1 | Optimisation of channelisation code utilisation for 1.28 Mcps TDD |  | 195d? | 2004-12-15 A | 2005-09-14 | 70% | 58.5d? | 2004-12-15 | 2005-09-14 | 195d? | 338d | finish no earlier than 2005-09-14 | R1 | 1560h | 1092h | RANimp-RABSE-CodOptLCRTDD | Rel-7 | TSG | Cesar | Ka Leong Lo | kaleong.lo@utstar.com |
| 78 | 22.2 | Delay optimisation for procedures applicable to CS and PS Connections |  | 261d? | 2005-03-15 | 2006-03-15 |  |  | 2005-03-15 | 2006-03-15 | 261d? | 208d | finish no earlier than 2006-03-15 | R2 | 2088h |  | RANimp-DelayOpt | Rel-7 | TSG | Cesar | Juho Pirskanen | juho.pirskanen@nokia.com |
| 79 | 22.3 | UE Performance Requirements for MBMS (TDD) |  | 261d? | 2005-03-15 | 2006-03-15 |  |  | 2005-03-15 | 2006-03-15 | 261d? | 208d | finish no earlier than 2006-03-15 | R4 | 2088h |  | MBMS-RAN-RF-TDD | Rel-7 | TSG | Cesar | Shin Horng Wong | shwong@ipwireless.com |
| 80 | 22.4 | Performance Evaluation of the UE behaviour in high speed trains with speeds up to 350 kmph |  | 261d? | 2005-03-15 A | 2006-03-14 | 5% | 247.95d? | 2005-03-15 | 2006-03-14 | 261d? | 208d | start no earlier than 2005-03-15 | R4 | 2088h | 104.4h | RANFS-HSTrains | Rel-7 | TSG | Cesar | Mike Vogel | Mike.vogel@vodafone.com |

Notes:
- 56: WI sent to NP#25 for approval / Text3: new TR, 24.229, 29.229, 29.163, 29.209
- 57: Duplicated entry ("ACCSEC2", "Access Security Enhancements", SP-040865) deleted by A.Sultan / Text3: 33.102, 43.020
- 58: Text3: 23.228
- 59: DAB - Not yet required in SA2 as it exists in previous releases
- 61: 27/11/2002 KK: WID approved at CN#18 (NP-020601)........
- 64: Approved at RP#25 as RP-040377 / Text3: TS25.101, TS25.104, TS25.133, TS25.141, TS25.331, TS25.942, TS25.306, TS25.307, TS34.121
- 65: Text3: 25.102, 25.105, 25.113, 25.123, 25.142, 25.331, 25.942, 25.306, 25.307, 34.122, 34.124
- 66: Text3: 25.101, 25.104, 25.113, 25.133, 25.141, 25.331, 25.942, 25.306, 25.307, 34.121
- 67: Text3: 25.101, 25.104, 25.113, 25.133, 25.141, 25.306, 25.307, 25.331, 34.121
- 68: Text3: TS25.101
- 69: Text3: 25.101
- 70: Approved at RP#25 as RP-040365
- 71: Approved at RP#25 as RP-040365 / Text3: New specification
- 72: Approved at RP#25 as RP-040365 / Text3: TS25.221, TS25.222, TS25.223, TS25.224,TS25.225
- 73: Approved at RP#25 as RP-040365 / Text3: TS25.301, TS25.302, TS25.305, TS25.306, TS25.321, TS25.331
- 74: Approved at RP#25 as RP-040365 / Text3: TS25.401, TS25.420, TS25.423, TS25.425, TS25.427, TS25.430, TS25.433, TS25.435
- 75: Approved at RP#25 as RP-040365 / Text3: TS25.102, TS25.105, TS25.123, TS25.133, TS25.142
- 76: Generic feature
- 78: Text3: TS25.321, TS25.322, TS25.331
- 79: Text3: TS25.102, TS25.123

| ID | WBS | Task | Type | Duration | Start | Finish | Complete | Remaining | Baseline start | Baseline finish | Baseline duration | Total slack | Constraint | Resources | Work | Actual work | Text1 | Text4 | Text5 | Text6 | Text7 | Text8 |
| --- | --- | --- | --- | --- | --- | --- | --- | --- | --- | --- | --- | --- | --- | --- | --- | --- | --- | --- | --- | --- | --- | --- |
| 81 | 23 | **3.84 Mcps TDD Enhanced Uplink** |  | 327d? | 2005-03-15 A | 2006-06-15 | 7% | 302.48d? | 2005-03-15 | 2006-06-15 | 327d? | 142d |  | RP | 13072h | 980.15h | EDCHTDD | Nicholas Anderson | nanderson@ipwireless.com | Rel-7 | TSG | Cesar |
| 82 | 23.1 | EDCHTDD: Stage 2 |  | 197d? | 2005-03-15 A | 2005-12-14 | 10% | 177.3d? | 2005-03-15 | 2005-12-14 | 197d? | 272d | start no earlier than 2005-03-15 | R2 | 1576h | 157.6h | EDCHTDD-Stage2 | Nicholas Anderson | nanderson@ipwireless.com | Rel-7 | TSG | Cesar |
| 83 | 23.2 | EDCHTDD: Physical Layer |  | 261d? | 2005-03-15 A | 2006-03-14 | 10% | 234.9d? | 2005-03-15 | 2006-03-14 | 261d? | 208d | start no earlier than 2005-03-15 | R1 | 2088h | 208.8h | EDCHTDD-Phys | Nicholas Anderson | nanderson@ipwireless.com | Rel-7 | TSG | Cesar |
| 84 | 23.3 | EDCHTDD: Layer 2 and 3 Protocol Aspects |  | 261d? | 2005-03-15 A | 2006-03-14 | 15% | 221.85d? | 2005-03-15 | 2006-03-14 | 261d? | 208d | start no earlier than 2005-03-15 | R2 | 2088h | 313.2h | EDCHTDD-L23 | Derek Richards | drichards@ipwireless.com | Rel-7 | TSG | Cesar |
| 85 | 23.4 | EDCHTDD: UTRAN Iub/Iur Protocol Aspects |  | 261d? | 2005-03-15 A | 2006-03-14 | 5% | 247.95d? | 2005-03-15 | 2006-03-14 | 261d? | 208d | start no earlier than 2005-03-15 | R3 | 2088h | 104.4h | EDCHTDD-IurIub | Jim Miller | jim.miller@interdigital.com | Rel-7 | TSG | Cesar |
| 86 | 23.5 | EDCHTDD: RF Radio Transmission/ Reception, System Performance Requirements and Conformance Testing |  | 327d? | 2005-03-15 | 2006-06-15 |  |  | 2005-03-15 | 2006-06-15 | 327d? | 142d | finish no earlier than 2006-06-15 | R4 | 2616h |  | EDCHTDD-RF | Shin Horng Wong | shwong@ipwireless.com | Rel-7 | TSG | Cesar |
| 87 | 24 | **Support of SMS and MMS over generic 3GPP IP access** |  | 173d? | 2004-10-14 A | 2005-06-13 | 99% | 0d? | 2004-10-14 | 2005-06-13 | 173d? | 404d |  | S2 | 2768h | 2560.4h | SMSIP |  |  | Rel-7 | TSG |  |
| 88 | 24.1 | FS on SMSIP |  | 173d? | 2004-10-14 A | 2005-06-13 A | 100% |  | 2004-10-14 | 2005-06-13 | 173d? |  | start no earlier than 2004-10-14 | S2 | 1384h | 1384h | SMSIP |  |  | Rel-7 |  |  |
| 89 | 24.2 | Stage 2 for SMSIP | milestone | 0d? | 2005-06-07 | 2005-06-07 |  |  | 2005-06-07 | 2005-06-07 | 0d? | 409d | finish no earlier than 2005-06-07 | S2 |  |  | SMSIP |  |  | Rel-7 |  |  |
| 90 | 25 | Evolution of Policy Control and Charging |  | 315d? | 2004-10-14 A | 2005-12-28 | 50% | 157.5d? | 2004-10-14 | 2005-12-28 | 315d? | 262d | finish no earlier than 2005-12-28 | S2 | 2520h | 1260h | PCC |  |  | Rel-7 | TSG | Maurice |
| 91 | 26 | **Advanced Global Navigation Satellite System (A-GNSS) concept** |  | 329d? | 2004-06-28 A | 2005-09-29 | 22% | 255.77d? | 2004-06-28 | 2005-09-29 | 329d? | 326d |  | S1 | 7241.6h | 1176.4h | LCS3-AGNSS | Michel MONNERAT | Michel.monnerat@space.alcatel.fr | Rel-7 | TSG | Michael |
| 92 | 26.1 | Support for GNSS in GERAN |  | 291.2d? | 2004-06-28 | 2005-09-02 |  |  | 2004-06-28 | 2005-09-02 | 291.2d? | 345d | finish no earlier than 2005-09-02 | GP | 2329.6h |  | AGNSS-GP | Richard Couty, ALCATEL SA | richard.couty@space.alcatel.fr | Rel-7 | TSG | Paolo |
| 93 | 26.2 | Towards A-GNSS Concept |  | 285d? | 2004-08-27 A | 2005-09-29 | 45% | 156.75d? | 2004-08-27 | 2005-09-29 | 285d? | 326d | finish no earlier than 2005-09-29 | S1 | 2280h | 1026h | GNSS | Richard Couty, ALCATEL SA | richard.couty@space.alcatel.fr | Rel-7 | TSG | Paolo |
| 94 | 27 | Video Codec Performance Requirements |  | 314d? | 2005-01-03 A | 2006-03-16 | 15% | 266.9d? | 2005-01-03 | 2006-03-16 | 314d? | 206d | finish no earlier than 2006-03-16 | S4 | 2512h | 376.8h | VICPer | Juergen Pandel (Siemens AG) | juergen.pandel@siemens.com | Rel-7 | TSG | Paolo |
| 95 | 28 | DIAMETER on the GGSN Gi interface |  | 266d? | 2004-09-10 | 2005-09-16 |  |  | 2004-09-10 | 2005-09-16 | 266d? | 335d | finish no earlier than 2005-09-16 | C3 | 2128h |  | DIAMGi | Stefan Koppenborg (T-Mobile) | stefan.koppenborg@t-mobile.de | Rel-7 | TSG | Seung Don |
| 96 | 29 | **CAMEL Trunk Triggers** |  | 251d? | 2004-12-17 A | 2005-12-05 | 53% | 119.22d? | 2004-12-17 | 2005-12-05 | 251d? | 279.5d |  | S1 | 6024h | 3162.6h | TTCAMEL | Amar Deol, Nortel Networks | deola@nortelnetworks.com | Rel-7 | TSG | Michael |
| 97 | 29.1 | Stage 1 for CAMEL Trunk Triggers |  | 251d? | 2004-12-17 A | 2005-12-05 | 95% | 12.55d? | 2004-12-17 | 2005-12-05 | 251d? | 279.5d |  | S1 | 2008h | 1907.6h | TTCAMEL | Amar Deol, Nortel Networks | deola@nortelnetworks.com | Rel-7 | TSG | Michael |
| 98 | 29.2 | CAMEL Trunk Originated Trigger Detection Points |  | 251d? | 2004-12-17 A | 2005-12-05 | 10% | 225.9d? | 2004-12-17 | 2005-12-05 | 251d? | 279.5d | start no earlier than 2004-12-17 | C4 | 2008h | 200.8h | CamelR7 | David Hutton, Nortel Networks | dhutton@nortel.com | Rel-7 | TSG | Kimmo |
| 99 | 30 | MS Antenna Performance Evaluation Method and Requirements |  | 206d? | 2005-01-28 | 2005-11-11 |  |  | 2005-01-28 | 2005-11-11 | 206d? | 295d | finish no earlier than 2005-11-11 | G1 | 1648h |  | APEMR | Ulf.Tegth (TeliaSonera) | Ulf.Tegth@teliasonera.com | Rel-7 | TSG | Paolo |
| 100 | 31 | Lower 700 MHz Inclusion in the GERAN Specifications |  | 106d? | 2005-01-28 A | 2005-06-24 | 70% | 31.8d? | 2005-01-28 | 2005-06-24 | 106d? | 395d | finish no earlier than 2005-06-24 | GP | 848h | 593.6h | GSM710 | Dave Cotton (UTC) | dcotton@mtview.union-tel.com | Rel-7 | TSG | Paolo |
| 101 | 32 | **3GPP System Architecture Evolution** |  | 401d? | 2004-12-03 A | 2006-06-16 | 8% | 367.12d? | 2004-12-03 | 2006-06-16 | 401d? | 140d |  | S2 | 8104h | 684.6h | SAE |  |  | Rel-7 | TSG |  |
| 102 | 32.1 | Stage 2 description of Interim conclusion |  | 211d? | 2004-12-03 A | 2005-09-23 | 15% | 179.35d? | 2004-12-03 | 2005-09-23 | 211d? | 330d | finish no earlier than 2005-09-23 | S2 | 1688h | 253.2h | SAE |  |  | Rel-7 |  |  |
| 103 | 32.2 | Stage 2 Feasibility study on 3GPP architectural development |  | 401d? | 2004-12-03 A | 2006-06-16 | 5% | 380.95d? | 2004-12-03 | 2006-06-16 | 401d? | 140d | finish no earlier than 2006-06-16 | S2 | 3208h | 160.4h | SAE |  |  | Rel-7 |  |  |
| 104 | 33 | **Enhancements of VGCS for public authority officials** |  | 0d? | 2004-08-27 A | 2004-08-27 |  | 0d? | 2004-08-27 | 2004-08-27 | 0d? | 611d |  | C1 |  |  | EGCS | Siemens |  | Rel-7 | TSG | Andrijana |
| 105 | 33.1 | Stage 1 | milestone | 0d? | 2004-08-27 A | 2004-08-27 A | 100% |  | 2004-08-27 | 2004-08-27 | 0d? |  | finish no earlier than 2004-08-27 | S1 |  |  | EGCS | Joerg Swetina (Siemens AG) | joerg.swetina@SIEMENS.COM | Rel-7 | TSG | Michael |
| 106 | 33.2 | GERAN2 aspects | milestone | 0d? | 2004-08-27 | 2004-08-27 |  |  | 2004-08-27 | 2004-08-27 | 0d? | 611d | finish no earlier than 2004-08-27 | G2 |  |  | EVGCS | Ken Isaacs (Siemens) | kenneth.isaacs@roke.co.uk | Rel-7 | TSG | Paolo |

Notes:
- 83: Text3: TS25.201, TS25.221,TS25.222, TS25.223, TS25.224, TS25.225
- 84: Text3: TS25.301, TS25.302, TS25.306, TS25.321, TS25.331
- 85: Text3: TS25.401, TS25.420, TS25.423, TS25.427, TS25.430, TS25.433, TS25.435
- 86: Text3: TS25.102, TS25.105, TS25.123, TS25.142
- 87: DAB - pushed back to June
- 92: Not started
- 94: Text3: 26.234, 26.235, 26.346, 26.140
- 95: Not started
- 98: Not started
- 99: Started / Text3: 25.9xx, 45.005
- 100: Started / Text3: 24.008, 43.022, 44.018, 44.118, 45, 001, 45.005, 51.010, 51.021
- 102: Text3: 23.8xx
- 103: Text3: 23.8xx
- 104: moved to Rel6 / Text3: 43.068, 44.068, 24.008, 29.002
- 105: Text3: 42.068, 43.068

| ID | WBS | Task | Type | Duration | Start | Finish | Complete | Remaining | Baseline start | Baseline finish | Baseline duration | Total slack | Constraint | Resources | Work | Actual work | Text1 | Text6 | Text3 | Text4 | Text5 | Text7 | Text8 | Text10 |
| --- | --- | --- | --- | --- | --- | --- | --- | --- | --- | --- | --- | --- | --- | --- | --- | --- | --- | --- | --- | --- | --- | --- | --- | --- |
| 107 | 34 | **Improvements of VGCS for parallel use of services** |  | 337d? | 2004-06-28 A | 2005-10-11 | 9% | 306.65d? | 2004-06-28 | 2005-10-11 | 337d? | 318d |  | C1 | 8312.02h | 748.68h | IVGCS | Rel-7 |  |  |  |  |  |  |
| 108 | 34.1 | Deleted - Enhancements of VGCS |  | 337d? | 2004-06-28 A | 2005-10-11 | 19% | 273.77d? | 2004-06-28 | 2005-10-11 | 337d? | 318d |  | S1 | 2696.02h | 505.85h | EGCS | Rel-7 | 42.068, 43.068 | Joerg Swetina (Siemens AG) | joerg.swetina@SIEMENS.COM | TSG | Michael |  |
| 109 | 34.2 | Deleted- Stage 1 |  | 161d? | 2005-03-01 | 2005-10-11 |  |  | 2005-03-01 | 2005-10-11 | 161d? | 318d | start no earlier than 2005-03-01 | S1 | 1288h |  | IVGCS | Rel-7 | 42.068 | Kurt Bischinger (T-Mobile) | kurt.bischinger@t-mobile.at | TSG | Michael |  |
| 110 | 34.3 | Service Requirements for VGCS improvements |  | 62d? | 2005-03-15 | 2005-06-08 |  |  | 2005-03-15 | 2005-06-08 | 62d? | 407d | finish no earlier than 2005-06-08 | S1 | 496h |  | IVGCS | Rel-7 | 42.068 | Kurt Bischinger (T-Mobile) | kurt.bischinger@t-mobile.at | TSG | Michael |  |
| 111 | 34.4 | Stage 2 modifications for VGCS improvements |  | 142d? | 2005-03-15 | 2005-09-28 |  |  | 2005-03-15 | 2005-09-28 | 142d? | 327d | finish no earlier than 2005-09-28 | C1 | 1136h |  | IVGCS | Rel-7 | 42.068 | Kurt Bischinger (T-Mobile) | kurt.bischinger@t-mobile.at | TSG |  |  |
| 112 | 35 | **Rel-7 OSA Service broker** |  | 142d? | 2005-03-15 A | 2005-09-28 | 20% | 113.95d? | 2005-03-15 | 2005-09-28 | 142d? | 327d |  | S1 | 2768h | 546.82h | OSA7-SB | Rel-7 |  | Eamonn Murray (AePONA) | eamonn.murray@aepona.com | TSG | Michael |  |
| 113 | 35.1 | Service Requirements for Service Broker |  | 62d? | 2005-03-15 A | 2005-06-08 | 65% | 21.7d? | 2005-03-15 | 2005-06-08 | 62d? | 407d | finish no earlier than 2005-06-08 | S1 | 496h | 322.4h | OSA7-SB | Rel-7 | 22.127 | Eamonn Murray (AePONA) | eamonn.murray@aepona.com | TSG | Michael |  |
| 114 | 35.2 | Stage 2 modifications for Service Broker |  | 142d? | 2005-03-15 | 2005-09-28 |  |  | 2005-03-15 | 2005-09-28 | 142d? | 327d | finish no earlier than 2005-09-28 | CT5 | 1136h |  | OSA7-SB | Rel-7 | 23.127 | Eamonn Murray (AePONA) | eamonn.murray@aepona.com | TSG | Adrian |  |
| 115 | 36 | Dynamic and interactive multimedia scenes |  | 194d? | 2005-03-15 A | 2005-12-09 | 5% | 184.3d? | 2005-03-15 | 2005-12-09 | 194d? | 275d | finish no earlier than 2005-12-09 | S4 | 1552h | 77.6h | DIMS | Rel-7 | 26.234, 23.346, 26.140, 26.244 | Gaëlle MARTIN-COCHER (Streamezzo) | gaelle.martin-cocher@streamezzo.com | TSG | Paolo |  |
| 116 | 37 | Liberty Alliance and 3GPP Security Interworking |  | 147d? | 2005-03-10 A | 2005-09-30 | 10% | 132.3d? | 2005-03-10 | 2005-09-30 | 147d? | 325d | finish no earlier than 2005-09-30 | S3 | 1176h | 117.6h | LibSec | Rel-7 |  | Silke Holtmanns, Nokia | Silke.Holtmanns@NOKIA.COM | TSG | Maurice |  |
| 117 | 38 | FS of enhanced support of Video Telephony |  | 266d? | 2004-08-27 A | 2005-09-02 | 35% | 172.9d? | 2004-08-27 | 2005-09-02 | 266d? | 345d | finish no earlier than 2005-09-02 | GP | 2128h | 744.8h | VIDGER | Rel-7 |  | Stefan Eriksson, Ericsson | stefan.g.eriksson@ericsson.com | TSG | Paolo |  |
| 118 | 39 | FS on Evolved UTRA and UTRAN |  | 130d? | 2004-12-15 A | 2005-06-15 | 20% | 104d? | 2004-12-15 | 2005-06-15 | 130d? | 403d | finish no earlier than 2005-06-15 | RP | 1040h | 208h | RANFS-Evo | Rel-7 |  | Takehiro Nakamura (NTT DoCoMo) | nakamurata@NTTDOCOMO.CO.JP | TSG | Cesar |  |
| 119 | 40 | **Study on Videotelephony teleservice** |  | 452d? | 2005-03-15 A | 2006-12-06 | 30% | 316.4d? | 2005-03-15 | 2006-12-06 | 452d? | 17d |  | S1 | 7232h | 2169.6h | VidTel | Rel-7 |  | Kurt Bischinger (T-Mobile) | kurt.bischinger@t-mobile.at | TSG | Michael |  |
| 120 | 40.1 | Study on Videotelephony service requirements |  | 452d? | 2005-03-15 A | 2006-12-06 | 30% | 316.4d? | 2005-03-15 | 2006-12-06 | 452d? | 17d | finish no earlier than 2006-12-06 | S1 | 3616h | 1084.8h | VidTel | Rel-7 | 22.101 | Kurt Bischinger (T-Mobile) | kurt.bischinger@t-mobile.at | TSG | Michael |  |
| 121 | 41 | **Study of Network Selection Principles** |  | 193d? | 2005-03-15 A | 2005-12-08 | 33% | 129.31d? | 2005-03-15 | 2005-12-08 | 193d? | 276d |  | S1 | 3088h | 1623.54h | NetSel | Rel-7 |  | Chris Friel (O2) | chris.friel@o2.com | TSG | Michael |  |
| 122 | 41.1 | Review of Network Selection Principles |  | 193d? | 2005-03-15 A | 2005-12-08 | 33% | 129.31d? | 2005-03-15 | 2005-12-08 | 193d? | 276d | finish no earlier than 2005-12-08 | S1 | 1544h | 509.52h | NetSel | Rel-7 | 22.811 | Chris Friel (O2) | chris.friel@o2.com | TSG | Michael |  |
| 123 | 42 | Behaviour of Multi system UEs |  | 188d? | 2004-06-28 A | 2005-03-16 | 60% | 75.2d? | 2004-06-28 | 2005-03-16 | 188d? | 467d | start no earlier than 2004-06-28 | S1 | 1504h | 902.4h | BMSU | Rel-7 | 22.936 | D Williams (QUALCOMM) | dwilliams@qualcomm.com | TSG | Michael |  |
| 124 | 43 | **WLAN-UMTS Interworking Phase 2** |  | 371d? | 2004-01-05 A | 2005-06-07 | 99% | 0d? | 2004-01-05 | 2005-06-07 | 371d? | 409d |  | S1 | 3888h | 3888h |  | Rel-7 |  | Fredric Paint, Telenor | frederic.paint@telenor.com | TSG | Michael |  |
| 125 | 43.1 | Stage 1 on Session Continuity |  | 115d? | 2004-01-05 A | 2004-06-11 A | 100% |  | 2004-01-05 | 2004-06-11 | 115d? |  | start no earlier than 2004-01-05 | S1 | 920h | 920h | WLAN-SC | Rel-7 |  |  |  |  |  | SP-24 |
| 126 | 43.2 | Stage 2 on Session Continuity: covered by SAE | milestone | 0d? | 2005-06-07 | 2005-06-07 |  |  | 2005-06-07 | 2005-06-07 | 0d? | 409d | finish no earlier than 2005-06-07 | S2 |  |  |  | Rel-7 |  |  |  |  |  |  |
| 127 | 44 | DIAMETER on the PDG Wi inteface |  | 266d? | 2004-09-10 | 2005-09-16 |  |  | 2004-09-10 | 2005-09-16 | 266d? | 335d | finish no earlier than 2005-09-16 | C3 | 2128h |  | DIAMWi | Rel-7 |  | Stefan Koppenborg (T-Mobile) | stefan.koppenborg@t-mobile.de | TSG | Seung Don |  |
| 128 | 45 | FS on Enhancements to support QoS provisioning over 3GPP/WLAN Interworking |  | 392d? | 2005-03-14 A | 2006-09-12 | 20% | 313.6d? | 2005-03-14 | 2006-09-12 | 392d? | 78d | start no earlier than 2005-03-14 | S2 | 3136h | 627.2h | WLAN-SC | Rel-7 |  | Osok Song, Samsung | osok.song@samsung.com |  | Maurice |  |
| 129 | 46 | Voice call continuity between CS and IMS (incl. I-WLAN) |  | 321d? | 2004-12-31 A | 2006-03-24 | 30% | 224.7d? | 2005-03-14 | 2005-12-24 | 205d? | 200d | start no earlier than 2004-12-31 | S2 | 2568h | 770.4h | VCC | Rel-7 | 22.101, 22.228, 23.228 | Andy Bennett, Lucent; Roger Bunting, Cingular | andybennett@lucent.com |  | Maurice |  |
| 130 | 47 | **OAM&P Rel-7** |  | 750d? | 2004-02-16 A | 2006-12-29 |  | 748.02d? | 2004-02-16 | 2006-12-29 | 750d? | 0d |  | S5 | 37088h | 3889.42h | OAM7 | Rel-7 | 32-series | Michael TRUSS (Motorola) | Michael.Truss@MOTOROLA.COM | TSG | Adrian |  |
| 131 | 47.1 | **Network Infrastructure Management** |  | 341d? | 2005-09-02 | 2006-12-22 |  |  | 2005-09-02 | 2006-12-22 | 341d? | 5d |  | S5 | 16400h |  | OAM7-NIM | Rel-7 |  | Michael TRUSS (Motorola) | Michael.Truss@MOTOROLA.COM |  |  |  |
| 132 | 47.1.1 | Enhance NRM to accommodate NGN (IMS as basis of the Next Generation Network) |  | 341d? | 2005-09-02 | 2006-12-22 |  |  | 2005-09-02 | 2006-12-22 | 341d? | 5d | finish no earlier than 2006-12-22 | S5 | 2728h |  | OAM7-NIM-NGN | Rel-7 |  | BT |  |  |  |  |
| 133 | 47.1.2 | IRP usage scenarios |  | 69d? | 2005-09-02 | 2005-12-07 |  |  | 2005-09-02 | 2005-12-07 | 69d? | 277d | finish no earlier than 2005-12-07 | S5 | 552h |  | OAM7-NIM | Rel-7 |  | Lucent |  |  |  |  |
| 134 | 47.1.3 | Co-operative Element Management interface (CO-OP) |  | 151d? | 2005-09-02 | 2006-03-31 |  |  | 2005-09-02 | 2006-03-31 | 151d? | 195d | finish no earlier than 2006-03-31 | S5 | 1208h |  | OAM7-NIM-COOP | Rel-7 |  | Motorola |  |  |  |  |
| 135 | 47.1.4 | Network Management (NM) Itf-N performance criteria |  | 69d? | 2005-09-02 | 2005-12-07 |  |  | 2005-09-02 | 2005-12-07 | 69d? | 277d | finish no earlier than 2005-12-07 | S5 | 552h |  | OAM7-NIM | Rel-7 |  | China Mobile |  |  |  |  |
| 136 | 47.1.5 | Delta synchronization between IRP Manager and IRP Agent |  | 69d? | 2005-09-02 | 2005-12-07 |  |  | 2005-09-02 | 2005-12-07 | 69d? | 277d | finish no earlier than 2005-12-07 | S5 | 552h |  | OAM7-NIM | Rel-7 |  | Siemens |  |  |  |  |
| 137 | 47.1.6 | Subscription Management (SuM) IRP Solution Sets |  | 151d? | 2005-09-02 | 2006-03-31 |  |  | 2005-09-02 | 2006-03-31 | 151d? | 195d | finish no earlier than 2006-03-31 | S5 | 1208h |  | OAM7-NIM-SuM | Rel-7 |  | T-Mobile |  |  |  |  |
| 138 | 47.1.7 | Integration Reference Point (IRP) Security Management |  | 216d? | 2005-09-02 | 2006-06-30 |  |  | 2005-09-02 | 2006-06-30 | 216d? | 130d | finish no earlier than 2006-06-30 | S5 | 1728h |  | OAM7-NIM | Rel-7 |  | Huawei |  |  |  |  |
| 139 | 47.1.8 | Integration Reference Point (IRP) Methodology |  | 69d? | 2005-09-02 | 2005-12-07 |  |  | 2005-09-02 | 2005-12-07 | 69d? | 277d | finish no earlier than 2005-12-07 | S5 | 552h |  | OAM7-NIM | Rel-7 |  | Ericsson |  |  |  |  |
| 140 | 47.1.9 | Partial suspension of Itf-N during maintenance/testing |  | 69d? | 2005-09-02 | 2005-12-07 |  |  | 2005-09-02 | 2005-12-07 | 69d? | 277d | finish no earlier than 2005-12-07 | S5 | 552h |  | OAM7-NIM | Rel-7 |  | Siemens |  |  |  |  |
| 141 | 47.1.10 | Advanced Alarming on Itf-N |  | 216d? | 2005-09-02 | 2006-06-30 |  |  | 2005-09-02 | 2006-06-30 | 216d? | 130d | finish no earlier than 2006-06-30 | S5 | 1728h |  | OAM7-NIM | Rel-7 |  | Siemens |  |  |  |  |
| 142 | 47.1.11 | Management of Legacy Equipment |  | 69d? | 2005-09-02 | 2005-12-07 |  |  | 2005-09-02 | 2005-12-07 | 69d? | 277d | finish no earlier than 2005-12-07 | S5 | 552h |  | OAM7-NIM | Rel-7 |  | Siemens |  |  |  |  |
| 143 | 47.1.12 | Rules for Vendor Specific Extensions |  | 151d? | 2005-09-02 | 2006-03-31 |  |  | 2005-09-02 | 2006-03-31 | 151d? | 195d | finish no earlier than 2006-03-31 | S5 | 1208h |  | OAM7-NIM | Rel-7 |  | Siemens |  |  |  |  |
| 144 | 47.1.13 | CN CS Bearer Transport Network (BTN) relative NRM |  | 69d? | 2005-09-02 | 2005-12-07 |  |  | 2005-09-02 | 2005-12-07 | 69d? | 277d | finish no earlier than 2005-12-07 | S5 | 552h |  | OAM7-NIM | Rel-7 |  | China Mobile |  |  |  |  |

Notes:
- 108: covered by Rel6's UID 11045
- 109: covered by UID 31070
- 115: Started
- 116: WID approved SA#27.
- 117: FS started
- 118: vice rapporteur Don Zelmar (Cingular)
- 123: This is a feature in its own right.
- 124: Created at TSG#27 by A. Sultan because of WLAN items belonging to Rel-7
- 127: Not started
- 128: Approved SA#27. BB Position in Work Plan to be confirmed
- 129: WID approved SA#27. Revised at SA#28.
- 130: Created at TSG#27 by A. Sultan due to the split of the OAM BB Trace Rel-6/Rel-7
- 131: SA#28 (06/2005) created
- 132: SA#28 (06/2005) created
- 133: SA#28 (06/2005) created
- 134: SA#28 (06/2005) created
- 135: SA#28 (06/2005) created
- 136: SA#28 (06/2005) created
- 137: SA#28 (06/2005) created
- 138: SA#28 (06/2005) created
- 139: SA#28 (06/2005) created
- 140: SA#28 (06/2005) created
- 141: SA#28 (06/2005) created
- 142: SA#28 (06/2005) created
- 143: SA#28 (06/2005) created
- 144: SA#28 (06/2005) created

| ID | WBS | Task | Type | Duration | Start | Finish | Complete | Remaining | Baseline start | Baseline finish | Baseline duration | Total slack | Constraint | Resources | Work | Actual work | Text1 | Text4 | Text5 | Text6 | Text7 | Text8 |
| --- | --- | --- | --- | --- | --- | --- | --- | --- | --- | --- | --- | --- | --- | --- | --- | --- | --- | --- | --- | --- | --- | --- |
| 145 | 47.2 | **Performance Management** |  | 346d? | 2005-09-02 | 2006-12-29 |  |  | 2005-09-02 | 2006-12-29 | 346d? | 0d |  | S5 | 8400h |  | OAM7-PM | Christian TOCHE (Nortel) | toche@NORTEL.COM | Rel-7 |  |  |
| 146 | 47.2.1 | erformance measurements definition for CN CS |  | 151d? | 2005-09-02 | 2006-03-31 |  |  | 2005-09-02 | 2006-03-31 | 151d? | 195d | finish no earlier than 2006-03-31 | S5 | 1208h |  | OAM7-PM | China Mobile |  | Rel-7 |  |  |
| 147 | 47.2.2 | Enhancement UTRAN performance measurements definition |  | 69d? | 2005-09-02 | 2005-12-07 |  |  | 2005-09-02 | 2005-12-07 | 69d? | 277d | finish no earlier than 2005-12-07 | S5 | 552h |  | OAM7-PM | China Mobile |  | Rel-7 |  |  |
| 148 | 47.2.3 | Add TDD specific counters in Performance measurement |  | 346d? | 2005-09-02 | 2006-12-29 |  |  | 2005-09-02 | 2006-12-29 | 346d? | 0d | finish no earlier than 2006-12-29 | S5 | 2768h |  | OAM7-PM | CATT |  | Rel-7 |  |  |
| 149 | 47.2.4 | ATM bearer network Performance measurements |  | 69d? | 2005-09-02 | 2005-12-07 |  |  | 2005-09-02 | 2005-12-07 | 69d? | 277d | finish no earlier than 2005-12-07 | S5 | 552h |  | OAM7-PM | ZTE |  | Rel-7 |  |  |
| 150 | 47.2.5 | IP bearer network Performance measurement definitions |  | 69d? | 2005-09-02 | 2005-12-07 |  |  | 2005-09-02 | 2005-12-07 | 69d? | 277d | finish no earlier than 2005-12-07 | S5 | 552h |  | OAM7-PM | China Mobile |  | Rel-7 |  |  |
| 151 | 44.5 | **Trace Management Rel-7** |  | 474d? | 2004-02-16 A | 2005-12-08 | 2% | 466.66d? | 2004-02-16 | 2005-12-08 | 474d? | 276d |  | S5 | 6288h | 97.42h | OAM-Trace | Christian TOCHE (Nortel) | toche@NORTEL.COM | Rel-7 | TSG |  |
| 152 | 47.3.1 | Trace Management for IMS |  | 154d? | 2005-05-09 A | 2005-12-08 | 5% | 146.3d? | 2005-05-09 | 2005-12-08 | 154d? | 276d | finish no earlier than 2005-12-08 | S5 | 1232h | 61.6h | OAM7-Trace-IMS | Nortel |  | Rel-7 | TSG |  |
| 153 | 47.3.2 | SIP enhancements for trace |  | 343d? | 2004-02-16 A | 2005-06-17 |  | 343d? | 2004-02-16 | 2005-06-17 | 343d? | 400.14d | finish no earlier than 2005-06-08 | C1 | 2744h |  | Trace-SIP |  |  | Rel-7 |  |  |
| 154 | 48 | **TBC: Generic User Profile Phase 2** |  | 820.4d | 2002-01-01 A | 2005-02-22 |  | 820.4d | 2002-01-01 | 2005-02-22 | 820.4d | 483.6d |  | C4 | 9376h |  |  |  |  | Rel-7 |  | Gaby |
| 155 | 30.4 | Stage 3 - Common objects |  | 586d | 2002-01-01 A | 2005-02-22 |  | 586d | 2002-01-01 | 2005-02-22 | 586d | 483.6d | finish no earlier than 2005-03-03 | C4 | 4688h |  |  |  |  | Rel-7 | TSG | Gaby |
| 156 | 49 | Deleted - IMS Phase 3 | milestone | 0d? | 2005-06-08 A | 2005-06-08 A | 100% |  | 2005-06-08 | 2005-06-08 | 0d? |  | finish no earlier than 2005-06-08 | S2 |  |  |  |  |  | Rel-7 |  |  |
| 157 | 50 | Deleted - Improvements of Radio Interface | milestone | 0d? | 2004-09-15 A | 2004-09-15 A | 100% |  | 2004-09-15 | 2004-09-15 | 0d? |  | start no earlier than 2004-09-15 | RP |  |  | RInImp |  |  | Rel-7 | TSG | Cesar |
| 158 | 51 | Trust Requirements for Open Platforms in 3GPP |  | 115d? | 2005-01-03 A | 2005-06-10 | 10% | 103.5d? | 2005-01-03 | 2005-06-10 | 115d? | 405d | finish no earlier than 2005-06-10 | S3 | 920h | 92h | TrustOP | Selim Aissi, Sundeep Bajikar, Intel Corporation | selim.aissi@intel.com; sundeep.bajikar@intel.com | Rel-7 | TSG | Michael |
| 159 | 52 | Development of UEA2 and UIA2 |  | 268d? | 2004-12-01 A | 2005-12-09 | 50% | 134d? | 2004-12-01 | 2005-12-09 | 268d? | 275d | finish no earlier than 2005-12-09 | S3 | 2144h | 1072h | AlgUEA2 | Per Christoffersson, Teliasonera | per.christoffersson@teliasonera.com | Rel-7 | TSG | Michael |
| 160 | 53 | Lawful Interception in the 3GPP Rel-7 architecture |  | 118d? | 2005-06-28 | 2005-12-08 |  |  | 2005-06-28 | 2005-12-08 | 118d? | 276d | start no earlier than 2005-06-28 | S3 | 944h |  | LI-7A | Berthold Wilhelm, BMWI | berthold.wilhelm@regtp.de | Rel-7 |  | Mike |
| 161 | 54 | **Support of Conversational Services in A/Gb mode via the PS domain** |  | 276d? | 2005-04-08 A | 2006-04-28 | 10% | 248.4d? | 2005-04-08 | 2006-04-28 | 276d? | 175d |  | GP | 8611.2h | 861.12h | SCSAGB | Gunnar Hedby, Ericsson | gunnar.hedby@ericsson.com | Rel-7 |  | Paolo |
| 162 | 54.1 | Definition of radio resource management functionality |  | 276d? | 2005-04-08 A | 2006-04-28 | 10% | 248.4d? | 2005-04-08 | 2006-04-28 | 276d? | 175d | finish no earlier than 2006-04-28 | G1 | 2208h | 220.8h | SCSAGB-RRM | Gunnar Hedby, Ericsson | gunnar.hedby@ericsson.com | Rel-7 |  | Paolo |
| 163 | 54.2 | Radio Channel Support |  | 276d? | 2005-04-08 A | 2006-04-28 | 10% | 248.4d? | 2005-04-08 | 2006-04-28 | 276d? | 175d | finish no earlier than 2006-04-28 | G2 | 2208h | 220.8h | SCSAGB-RCHS | Gunnar Hedby, Ericsson | gunnar.hedby@ericsson.com | Rel-7 |  | Gert |
| 164 | 54.3 | Modifications to FLO |  | 276d? | 2005-04-08 A | 2006-04-28 | 10% | 248.4d? | 2005-04-08 | 2006-04-28 | 276d? | 175d | finish no earlier than 2006-04-28 | G2 | 2208h | 220.8h | SCSAGB-FLO | Gunnar Hedby, Ericsson | gunnar.hedby@ericsson.com | Rel-7 |  | Gert |
| 165 | 55 | **Addition of new frequency band to GSM (T-GSM810)** |  | 106d? | 2005-04-08 | 2005-09-02 |  |  | 2005-04-08 | 2005-09-02 | 106d? | 345d |  | GP | 2992h |  | T-GSM810 | Chen De, Huawei | chende@huawei.com | Rel-7 |  | Paolo |
| 166 | 55.1 | Changes to core specification |  | 56d? | 2005-04-08 | 2005-06-24 |  |  | 2005-04-08 | 2005-06-24 | 56d? | 395d | finish no earlier than 2005-06-24 | GP | 448h |  | T-GSM810-Core | Chen De, Huawei | chende@huawei.com | Rel-7 |  | Paolo |
| 167 | 55.2 | Changes to MS testing specification |  | 106d? | 2005-04-08 | 2005-09-02 |  |  | 2005-04-08 | 2005-09-02 | 106d? | 345d | finish no earlier than 2005-09-02 | G3 | 848h |  | T-GSM810-Mstest | Chen De, Huawei | chende@huawei.com | Rel-7 |  | Stoyan |
| 168 | 55.3 | Changes to BTS testing specification |  | 106d? | 2005-04-08 | 2005-09-02 |  |  | 2005-04-08 | 2005-09-02 | 106d? | 345d | finish no earlier than 2005-09-02 | G1 | 848h |  | T-GSM810-BTStest | Chen De, Huawei | chende@huawei.com | Rel-7 |  | Paolo |

Notes:
- 145: SA#28 (06/2005) created
- 148: SA#28 (06/2005) created
- 149: SA#28 (06/2005) created
- 150: SA#28 (06/2005) created
- 151: TSG#27: SA5 BB WID to add Trace for IMS (SIP) CN1 24.229 has IETF dependency
- 152: Text3: 32.421/2/3
- 154: Created at TSG#27 by A. Sultan because of the move to Rel-7 of "Common Objects".
- 155: No progress in CN4#26. This have to be moved to Rel-7. It was deleted from WID / Text3: 24.241
- 157: This is a generic feature without particular end date
- 158: WID approved SA#26. Record created after SA#27
- 159: WID approved SA#26, Dependant on Funding Availability. Record created after SA#27 / Text3: 33.102
- 165: Text3: 45.005, 45.050, 24.008, 45.008, 45.001, 43.022, 43.030, 44.018, 44.060, 51.010-1, 51.021
- 166: Text3: 45.005, 45.050, 24.008, 45.008, 45.001, 43.022, 43.030, 44.018, 44.060
- 167: Text3: 51010-1
- 168: Text3: 51021

| ID | WBS | Task | Duration | Start | Finish | Complete | Remaining | Baseline start | Baseline finish | Baseline duration | Total slack | Constraint | Resources | Work | Actual work | Text1 | Text3 | Text4 | Text5 | Text6 | Text8 | Text7 |
| --- | --- | --- | --- | --- | --- | --- | --- | --- | --- | --- | --- | --- | --- | --- | --- | --- | --- | --- | --- | --- | --- | --- |
| 169 | 56 | **Handover of dedicated and shared resources while in dual transfer mode** | 421d? | 2005-04-08 | 2006-11-17 |  |  | 2005-04-08 | 2006-11-17 | 421d? | 30d |  | GP | 10104h |  | HO-DSRDTM | 43.055, 44.018, 44.060 | Rami Vaittinen, Nokia | rami.vaittinen@nokia.com | Rel-7 | Paolo |  |
| 170 | 56.1 | MS conformance testing | 421d? | 2005-04-08 | 2006-11-17 |  |  | 2005-04-08 | 2006-11-17 | 421d? | 30d | finish no earlier than 2006-11-17 | G3 | 3368h |  | HO-DSRDTM-MStest | 51010-1 | Rami Vaittinen, Nokia | rami.vaittinen@nokia.com | Rel-7 | Stoyan |  |
| 171 | 56.2 | BTS conformance testing | 421d? | 2005-04-08 | 2006-11-17 |  |  | 2005-04-08 | 2006-11-17 | 421d? | 30d | finish no earlier than 2006-11-17 | G1 | 3368h |  | HO-DSRDTM-BTStest |  | Rami Vaittinen, Nokia | rami.vaittinen@nokia.com | Rel-7 | Paolo |  |
| 172 | 57 | Future GERAN Evolution | 156d? | 2005-04-08 A | 2005-11-11 | 5% | 148.2d? | 2005-04-08 | 2005-11-11 | 156d? | 295d | finish no earlier than 2005-11-11 | GP | 1248h | 62.4h | FGE |  | Eddie Riddington, Nokia Corporation | eddie.riddington@nokia.com | Rel-7 | Paolo |  |
| 173 | 58 | 3G-324M Video Telephony Call Setup Times Improvements | 391d? | 2005-06-08 | 2006-12-06 |  |  | 2005-06-08 | 2006-12-06 | 391d? | 17d | finish no earlier than 2006-12-06 | S4 | 3128h |  | VTCSTI | 26.abc | Edward Hall (Vodafone) | edward.hall@vodafone.co.uk | Rel-7 | Paolo |  |
| 174 | 59 | Personal Network (PN) and Personal Area Network (PAN) | 101.2d? | 2005-07-11 | 2005-12-08 |  |  | 2005-07-11 | 2005-12-08 | 101.2d? | 276d | finish no earlier than 2005-12-08 | S1 | 809.6h |  | PNPAN |  | Armin Toepfer, Vodafone | armin.toepfer@vodafone.com | Rel-7 | Mike |  |
| 175 | 60 | Multimedia Telephony Capabilities for IMS | 101.2d? | 2005-07-11 | 2005-12-08 |  |  | 2005-07-11 | 2005-12-08 | 101.2d? | 276d | finish no earlier than 2005-12-08 | S1 | 809.6h |  | MITE |  | Peter Bleckert, Ericsson | peter.bleckert @ericsson.com | Rel-7 | Mike |  |
| 176 | 61 | Transferring of emergency Call data | 109d? | 2005-07-11 | 2005-12-08 |  |  | 2005-07-11 | 2005-12-08 | 109d? | 276d | finish no earlier than 2005-12-08 | S1 | 872h |  | eCALL |  | Steve Vardy, (Motorola S.A.S) | steven.vardy@motorola.com | Rel-7 | Mike |  |
| 177 | 62 | MBMS Enhancements | 109d? | 2005-07-11 | 2005-12-08 |  |  | 2005-07-11 | 2005-12-08 | 109d? | 276d | finish no earlier than 2005-12-08 | S1 | 872h |  | MBMSE |  | Liu Hong, China Mobile | liuhongyfw@chinamobile.com | Rel-7 | Mike |  |
| 178 | 63 | NEW!! FS on Continuous connectivity for packet data users | 132d? | 2005-03-15 | 2005-09-15 |  |  | 2005-03-15 | 2005-09-15 | 132d? | 337d | finish no earlier than 2005-09-15 | R1 | 1056h |  | RANFS-cont-packet |  | Joerg Gustrau | joerg.gustrau@siemens.com | Rel-7 | Cesar | TSG |
| 179 | 64 | NEW!! FS onUTRA Tower Mounted Amplifier (FDD) | 195d? | 2005-06-15 | 2006-03-15 |  |  | 2005-06-15 | 2006-03-15 | 195d? | 208d | finish no earlier than 2006-03-15 | R4 | 1560h |  | RANFS-TMA |  | Klas Sjerling | Klas.Sjerling@ericsson.com | Rel-7 | Cesar | TSG |
| 180 | 65 | Identification of Communication Services in IMS | 321d? | 2005-05-02 A | 2006-07-24 | 5% | 304.95d? | 2005-05-02 | 2006-07-24 | 321d? | 114d | start no earlier than 2005-05-02 | S2 | 2568h | 128.4h | ServID | 23.228, 23.218, 23.125 | Stephen Terrill, Ericsson | stephen.terrill@ericsson.com | Rel-7 | Maurice |  |
| 181 | 66 | FS on enhancement of radio performance for VoIMS | 321d? | 2005-05-02 A | 2006-07-24 | 5% | 304.95d? | 2005-05-02 | 2006-07-24 | 321d? | 114d | start no earlier than 2005-05-02 | S2 | 2568h | 128.4h | VoIMS |  | Laurence Lautier, Nortel Networks | lautierl@nortel.com | Rel-7 | Maurice |  |
| 182 | 67 | (check Release) Improved support of IMS Realtime Services using HSDPA/HSUPA | 197d? | 2005-03-15 A | 2005-12-14 | 15% | 167.45d? | 2005-03-15 | 2005-12-14 | 197d? | 272d | start no earlier than 2005-03-15 | R2 | 1576h | 236.4h | RInImp-IMSRealTime |  | Don Zelmer | don.zelmer@CINGULAR.COM | Rel-7 | Cesar | TSG |
| 183 | 68 | Performance Characterization of VoIMS over HSDPA\EUL channels20028 | 262d? | 2005-03-15 A | 2006-03-15 | 5% | 248.9d? | 2005-03-15 | 2006-03-15 | 262d? | 207d | finish no earlier than 2006-03-15 | S4 | 2096h | 104.8h | PCVoIMS | 26.935 | Dimitris Vasilaras (Lucent Technologies) | dvasilaras@lucent.com | Rel-7 | Paolo | TSG |

Notes:
- 169: Not started
- 170: Not started
- 171: Not started
- 172: FS started
- 173: Conditionally, in the event Phase 2 is needed, end is Dec.06
- 180: WID approved SA#28
- 181: WID approved SA#28
- 183: Started
